# projeck hung

Schedule from MS Project, 2015-10-03 to 2016-05-31.

## Calendars

- Standard: Mon-Fri 08:00-12:00, 13:00-17:00; Sat-Sun 07:00-12:00, 13:00-17:00.

## Resources

| Resource |
| --- |
| NC(16) |
| NC(10) |
| NC(36) |
| NC(6 |
| NC(34) |
| NC(27) |
| NC(11) |
| NC(5 |
| NC(7 |
| NC(14) |
| NC(3 |
| NC(8 |
| NC(17) |
| NC(25) |
| NC(26) |
| NC(13) |
| NC(4 |
| NC(1 |
| NC(24) |
| NC(15) |
| NC(23) |
| NC(19) |
| NC(9 |
| NC(2 |
| NC(21) |
| NC(22) |
| NC(28) |
| NC(32) |
| NC(4) |
| NC(3) |
| NC |

## Schedule

| ID | WBS | Task | Duration | Start | Finish | Predecessors | Total slack | Free slack | Constraint | Resources | Work | Text1 | Text2 | Text3 | Text4 |
| --- | --- | --- | --- | --- | --- | --- | --- | --- | --- | --- | --- | --- | --- | --- | --- |
| 1 | 1 | **tæng tiÕn ®é thi c«ng** | 250d | 2015-10-03 | 2016-05-31 |  | 0d |  |  |  | 101328h |  |  |  |  |
| 2 | 1.1 | c«ng t¸c chuÈn bÞ | 2d | 2015-10-03 | 2015-10-04 |  | 0d |  |  | NC [3000%] | 480h | c«ng |  |  |  |
| 3 | 1.2 | **phÇn ngÇm** | 48d | 2015-10-04 | 2015-11-20 |  | 0d |  |  |  | 16400h |  |  |  |  |
| 4 | 1.2.1 | Ðp tr­íc cäc BTCT ®Êt cÊp II (cäc 25x25) 2 m¸y Ðp 3 ca trong 1 ngµy | 24d | 2015-10-04 | 2015-10-28 | 2 | 0d |  |  | NC [4800%] | 9216h | 100m | 47,76 | 3,05 | 146 |
| 5 | 1.2.2 | §µo ®Êt mãng b»ng m¸y ( 1 m¸y lµm 2 ca trong 1 ngµy) | 1d | 2015-10-28 | 2015-10-29 | 4 | 0d |  |  | NC [1600%] | 128h | 100m3 | 7,42 | 0,29 |  |
| 6 | 1.2.3 | §µo mãng b»ng thñ c«ng | 8d | 2015-10-29 | 2015-11-05 | 5SS+1d | 0d |  |  | NC [4500%] | 2880h | c«ng/m3 | 463,9 | 0,77 | 357 |
| 7 | 1.2.4 | Ph¸ BT ®Çu cäc | 1d | 2015-11-05 | 2015-11-06 | 6 | 0d |  |  | NC [600%] | 48h | m3 | 8,84 | 0,72 |  |
| 8 | 1.2.5 | §æ BT lãt mãng + gi»ng mãng b»ng thñ c«ng | 2d | 2015-11-05 | 2015-11-07 | 7SS | 0d |  |  | NC [2500%] | 400h | m3 | 41,58 | 1,18 | 49 |
| 9 | 1.2.6 | G.C.L.D cèt thÐp ®µi + gi»ng ( lÊy d = 18mm) | 6d | 2015-11-07 | 2015-11-13 | 8 | 0d |  |  | NC [2900%] | 1392h |  | 20,55 | 8,34 | 171 |
| 10 | 1.2.7 | GCLD VK ®µi , gi»ng 75% | 6d | 2015-11-08 | 2015-11-14 | 9SS+1d | 0d |  |  | NC [2300%] | 1104h | 100m2 | 6,07 | 22,27 | 135 |
| 11 | 1.2.8 | §æ BT ®µi, gi»ng b»ng m¸y b¬m (60m3/h) 70% | 1d | 2015-11-14 | 2015-11-15 | 10, 9 | 0d |  |  | NC [2000%] | 160h | m3 | 205,44 | 20 c«ng/ca |  |
| 12 | 1.2.9 | Dì c«p pha ®µi, gi»ng mãng 25% | 2d | 2015-11-15 | 2015-11-17 | 11 | 0d |  |  | NC [2300%] | 368h | 100m2 | 6,07 | 7,42 | 45 |
| 13 | 1.2.10 | GCLD cèt thÐp cæ cét | 1d | 2015-11-15 | 2015-11-16 | 12SS | 0d |  |  | NC [1100%] | 88h |  | 1,1 | 8,48 |  |
| 14 | 1.2.11 | GCLD VK cæ cét | 1d | 2015-11-16 | 2015-11-17 | 13SS+1d | 0d |  |  | NC [1600%] | 128h | 100m2 | 0,74 | 19,14 | 14 |
| 15 | 1.2.12 | §æ BT cæ cét b»ng thñ c«ng | 1d | 2015-11-17 | 2015-11-18 | 14, 13 | 0d |  |  | NC [2800%] | 224h | m3 | 6,94 | 4,05 | 28 |
| 16 | 1.2.13 | Th¸o dì VK cæ cét 25% | 1d | 2015-11-18 | 2015-11-19 | 15 | 0d |  |  | NC [800%] | 64h | 100m2 | 0,74 | 6,38 |  |
| 17 | 1.2.14 | LÊp ®Êt hè mãng + thñ c«ng | 1d | 2015-11-19 | 2015-11-20 | 16 | 0d |  |  | NC [2500%] | 200h | 100m3 | 9,93 | 0,12 |  |
| 18 | 1.3 | **phÇn th©n** | 192d | 2015-11-20 | 2016-05-23 |  | 0d |  |  |  | 72440h |  |  |  |  |
| 19 | 1.3.1 | **tÇng 1** | 192d | 2015-11-20 | 2016-05-23 |  | 0d |  |  |  | 10528h |  |  |  |  |
| 20 | 1.3.1.1 | GCLD cèt thÐp cét, v¸ch lâi thang m¸y (h <4m) d> 18mm | 2d | 2015-11-20 | 2015-11-22 | 17 | 0d |  |  | NC [2600%] | 416.02h |  | 5,97 | 8,48 | 51 |
| 21 | 1.3.1.2 | GCLD VK cét, v¸ch lâi thang m¸y 75% (h<16m) | 3d | 2015-11-21 | 2015-11-24 | 20SS+1d | 0d |  | start no earlier than 2015-11-21 | NC [2500%] | 600h | 100m2 | 3,97 | 19,14 | 76 |
| 22 | 1.3.1.3 | §æ BT cét, v¸ch lâi thang m¸y b»ng b¬m (60m3/h) 70% | 1d | 2015-11-24 | 2015-11-25 | 21, 20 | 0d |  |  | NC [2000%] | 160h | m3 | 38,03 | 20 c«ng/ca |  |
| 23 | 1.3.1.4 | Th¸o dì VK cét , v¸ch lâi thang m¸y 25% | 3d | 2015-11-26 | 2015-11-28 | 22FS+1d | 0d |  |  | NC [800%] | 192h | 100m2 | 3,97 | 6,38 | 25 |
| 24 | 1.3.1.5 | GCLD VK dÇm, sµn 75% (h<16m) | 7d | 2015-11-27 | 2015-12-03 | 23SS+1d | 0d |  |  | NC [2200%] | 1232h | 100m2 | 9,67 | 16,09 | 156 |
| 25 | 1.3.1.6 | GCLD cèt thÐp dÇm, sµn (h<4m) | 6d | 2015-11-28 | 2015-12-03 | 24SS+1d | 0d |  |  | NC [1300%] | 624h |  | 8,22 | 9,1 | 75 |
| 26 | 1.3.1.7 | §æ BT dÇm, sµn b»ng m¸y b¬m (60m3/h) 70% | 1d | 2015-12-03 | 2015-12-04 | 25, 24 | 0d |  |  | NC [2000%] | 160h | m3 | 104,65 | 20 c«ng/ca |  |
| 27 | 1.3.1.8 | Th¸o dì v¸n khu«n dÇm, sµn 25% | 6d | 2015-12-27 | 2016-01-01 | 26FS+23d | 0d |  |  | NC [900%] | 432h | 100m2 | 9,67 | 5,36 | 52 |
| 28 | 1.3.1.9 | X©y t­êng chÌn (h<4m) | 17d | 2016-01-01 | 2016-01-18 | 27 | 0d |  |  | NC [1800%] | 2448h | m3 | 163,25 | 1,92 | 313 |
| 29 | 1.3.1.10 | GCLD VK cÇu thang 75% ( h<16m) | 1d | 2016-01-02 | 2016-01-03 | 28SS+1d | 144d | 0d |  | NC [400%] | 32h | 100m2 | 0,27 | 16,09 |  |
| 30 | 1.3.1.11 | GCLD cèt thÐp cÇu thang 75% ( h<4m) | 1d | 2016-01-03 | 2016-01-04 | 29 | 144d | 0d |  | NC [400%] | 32h |  | 0,3 | 14,41 |  |
| 31 | 1.3.1.12 | §æ BT cÇu thang b»ng thñ c«ng | 1d | 2016-01-04 | 2016-01-05 | 30, 29 | 144d | 0d |  | NC [1100%] | 88h | m3 | 3,78 | 2,9 | 11 |
| 32 | 1.3.1.13 | Th¸o dì VK cÇu thang 25% | 1d | 2016-01-12 | 2016-01-13 | 31FS+7d | 144d |  |  | NC [200%] | 16h | 100m2 | 0,27 | 5,36 |  |
| 33 | 1.3.1.14 | Tr¸t t­êng trong + trÇn | 17d | 2016-01-18 | 2016-02-03 | 28 | 0d |  |  | NC [2400%] | 3264h | m2 | 2065,05 | 0.2 | 413 |
| 34 | 1.3.1.15 | L¸t nÒn, sµn | 4d | 2016-05-19 | 2016-05-23 | 50 | 8d |  |  | NC [2600%] | 832h | m2 | 610,75 | 0,17 | 104 |

| ID | WBS | Task | Duration | Start | Finish | Predecessors | Total slack | Free slack | Resources | Work | Text2 | Text3 | Text4 | Text1 |
| --- | --- | --- | --- | --- | --- | --- | --- | --- | --- | --- | --- | --- | --- | --- |
| 35 | 1.3.2 | **tÇng 2** | 172d | 2015-12-05 | 2016-05-19 |  | 0d |  |  | 10040h |  |  |  |  |
| 36 | 1.3.2.1 | GCLD cèt thÐp cét, v¸ch lâi thang m¸y (h <16m) d> 18mm | 3d | 2015-12-05 | 2015-12-08 | 26FS+1d | 0d |  | NC [1500%] | 360h | 5,09 | 8,85 | 45 |  |
| 37 | 1.3.2.2 | GCLD VK cét, v¸ch lâi thang m¸y 75% (h<16m) | 3d | 2015-12-06 | 2015-12-09 | 36SS+1d | 0d |  | NC [2300%] | 552h | 3,54 | 19,14 | 68 | 100m2 |
| 38 | 1.3.2.3 | §æ BT cét, v¸ch lâi thang m¸y b»ng b¬m(60m3/h) 70% | 1d | 2015-12-09 | 2015-12-10 | 37, 36 | 0d |  | NC [2000%] | 160h | 32,44 | 20 c«ng/ca |  | m3 |
| 39 | 1.3.2.4 | Th¸o dì VK cét , v¸ch lâi thang m¸y 25% | 3d | 2015-12-11 | 2015-12-14 | 38FS+1d | 0d |  | NC [800%] | 192h | 3,54 | 6,38 | 23 | 100m2 |
| 40 | 1.3.2.5 | GCLD VK dÇm, sµn 75% (h<16m) | 8d | 2015-12-12 | 2015-12-20 | 39SS+1d | 0d |  | NC [1900%] | 1216h | 9,41 | 16,09 | 151 | 100m2 |
| 41 | 1.3.2.6 | GCLD cèt thÐp dÇm, sµn (h<16m) | 7d | 2015-12-13 | 2015-12-20 | 40SS+1d | 0d |  | NC [1000%] | 560h | 7,71 | 9,17 | 71 |  |
| 42 | 1.3.2.7 | §æ BT dÇm, sµn b»ng m¸y b¬m(60m3/h) 70% | 1d | 2015-12-20 | 2015-12-21 | 41, 40 | 0d |  | NC [2000%] | 160h | 98,19 | 20 c«ng/ca |  | m3 |
| 43 | 1.3.2.8 | Th¸o dì v¸n khu«n dÇm, sµn 25% | 6d | 2016-01-12 | 2016-01-18 | 42FS+23d | 0d |  | NC [800%] | 384h | 9,41 | 5,36 | 50 | 100m2 |
| 44 | 1.3.2.9 | X©y t­êng chÌn (h<16m) | 17d | 2016-01-18 | 2016-02-03 | 43, 28 | 0d |  | NC [1700%] | 2312h | 148,9 | 1,97 | 293 | m3 |
| 45 | 1.3.2.10 | GCLD VK cÇu thang 75% ( h<16m) | 1d | 2016-01-22 | 2016-01-23 | 44SS+4d | 124d | 0d | NC [500%] | 40h | 0,31 | 16,09 |  | 100m2 |
| 46 | 1.3.2.11 | GCLD cèt thÐp cÇu thang 75% ( h<16m) | 1d | 2016-01-23 | 2016-01-23 | 45 | 124d | 0d | NC [400%] | 32h | 0,3 | 14,63 |  |  |
| 47 | 1.3.2.12 | §æ BT cÇu thang b»ng thñ c«ng | 1d | 2016-01-24 | 2016-01-24 | 46, 45 | 124d | 0d | NC [1100%] | 88h | 3,95 | 2,9 | 11 | m3 |
| 48 | 1.3.2.13 | Th¸o dì VK cÇu thang 25% | 1d | 2016-01-31 | 2016-02-01 | 47FS+7d | 124d |  | NC [200%] | 16h | 0,31 | 5,36 |  | 100m2 |
| 49 | 1.3.2.14 | Tr¸t t­êng trong + trÇn | 17d | 2016-02-03 | 2016-02-20 | 44, 33 | 0d |  | NC [2300%] | 3128h | 1917,87 | 0.2 | 384 | m2 |
| 50 | 1.3.2.15 | L¸t nÒn, sµn | 5d | 2016-05-15 | 2016-05-19 | 66 | 8d | 0d | NC [2100%] | 840h | 610,75 | 0,17 | 104 | m2 |
| 51 | 1.3.3 | **tÇng 3** | 150d | 2015-12-22 | 2016-05-14 |  | 0d |  |  | 10040h |  |  |  |  |
| 52 | 1.3.3.1 | GCLD cèt thÐp cét, v¸ch lâi thang m¸y (h <16m) d> 18mm | 3d | 2015-12-22 | 2015-12-25 | 42FS+1d | 0d |  | NC [1500%] | 360h | 5,09 | 8,85 | 45 |  |
| 53 | 1.3.3.2 | GCLD VK cét, v¸ch lâi thang m¸y 75% (h<16m) | 3d | 2015-12-23 | 2015-12-26 | 52SS+1d | 0d |  | NC [2300%] | 552h | 3,54 | 19,14 | 68 | 100m2 |
| 54 | 1.3.3.3 | §æ BT cét, v¸ch lâi thang m¸y b»ng b¬m(60m3/h) 70% | 1d | 2015-12-26 | 2015-12-26 | 53, 52 | 0d |  | NC [2000%] | 160h | 32,44 | 20 c«ng/ca |  | m3 |
| 55 | 1.3.3.4 | Th¸o dì VK cét , v¸ch lâi thang m¸y 25% | 3d | 2015-12-27 | 2015-12-30 | 54FS+1d | 0d |  | NC [800%] | 192h | 3,54 | 6,38 | 23 | 100m2 |
| 56 | 1.3.3.5 | GCLD VK dÇm, sµn 75% (h<16m) | 8d | 2015-12-28 | 2016-01-05 | 55SS+1d | 0d |  | NC [1900%] | 1216h | 9,41 | 16,09 | 151 | 100m2 |
| 57 | 1.3.3.6 | GCLD cèt thÐp dÇm, sµn (h<16m) | 7d | 2015-12-29 | 2016-01-05 | 56SS+1d | 0d |  | NC [1000%] | 560h | 7,71 | 9,17 | 71 |  |
| 58 | 1.3.3.7 | §æ BT dÇm, sµn b»ng m¸y b¬m(60m3/h) 70% | 1d | 2016-01-05 | 2016-01-06 | 57, 56 | 0d |  | NC [2000%] | 160h | 98,19 | 20 c«ng/ca |  | m3 |
| 59 | 1.3.3.8 | Th¸o dì v¸n khu«n dÇm, sµn 25% | 6d | 2016-01-28 | 2016-02-03 | 58FS+23d | 0d |  | NC [800%] | 384h | 9,41 | 5,36 | 50 | 100m2 |
| 60 | 1.3.3.9 | X©y t­êng chÌn (h<16m) | 17d | 2016-02-03 | 2016-02-20 | 59, 44 | 0d |  | NC [1700%] | 2312h | 148,9 | 1,97 | 293 | m3 |
| 61 | 1.3.3.10 | GCLD VK cÇu thang 75% ( h<16m) | 1d | 2016-02-07 | 2016-02-08 | 60SS+4d | 107d | 0d | NC [500%] | 40h | 0,31 | 16,09 |  | 100m2 |
| 62 | 1.3.3.11 | GCLD cèt thÐp cÇu thang 75% ( h<16m) | 1d | 2016-02-08 | 2016-02-09 | 61 | 107d | 0d | NC [400%] | 32h | 0,3 | 14,63 |  |  |
| 63 | 1.3.3.12 | §æ BT cÇu thang b»ng thñ c«ng | 1d | 2016-02-09 | 2016-02-10 | 62, 61 | 107d | 0d | NC [1100%] | 88h | 3,95 | 2,9 | 11 | m3 |
| 64 | 1.3.3.13 | Th¸o dì VK cÇu thang 25% | 1d | 2016-02-17 | 2016-02-18 | 63FS+7d | 107d |  | NC [200%] | 16h | 0,31 | 5,36 |  | 100m2 |
| 65 | 1.3.3.14 | Tr¸t t­êng trong + trÇn | 17d | 2016-02-20 | 2016-03-07 | 60, 49 | 0d |  | NC [2300%] | 3128h | 1917,87 | 0.2 | 384 | m2 |
| 66 | 1.3.3.15 | L¸t nÒn, sµn | 5d | 2016-05-10 | 2016-05-14 | 82 | 8d | 0d | NC [2100%] | 840h | 610,75 | 0,17 | 104 | m2 |

| ID | WBS | Task | Duration | Start | Finish | Predecessors | Total slack | Free slack | Resources | Work | Text2 | Text3 | Text4 | Text1 |
| --- | --- | --- | --- | --- | --- | --- | --- | --- | --- | --- | --- | --- | --- | --- |
| 67 | 1.3.4 | **tÇng 4** | 128d | 2016-01-07 | 2016-05-10 |  | 0d |  |  | 10040h |  |  |  |  |
| 68 | 1.3.4.1 | GCLD cèt thÐp cét, v¸ch lâi thang m¸y (h <16m) d> 18mm | 3d | 2016-01-07 | 2016-01-10 | 58FS+1d | 0d |  | NC [1500%] | 360h | 5,09 | 8,85 | 45 |  |
| 69 | 1.3.4.2 | GCLD VK cét, v¸ch lâi thang m¸y 75% (h<16m) | 3d | 2016-01-08 | 2016-01-11 | 68SS+1d | 0d |  | NC [2300%] | 552h | 3,54 | 19,14 | 68 | 100m2 |
| 70 | 1.3.4.3 | §æ BT cét, v¸ch lâi thang m¸y b»ng b¬m (60m3/h) 70% | 1d | 2016-01-11 | 2016-01-12 | 69, 68 | 0d |  | NC [2000%] | 160h | 32,44 | 20 c«ng/ca |  | m3 |
| 71 | 1.3.4.4 | Th¸o dì VK cét , v¸ch lâi thang m¸y 25% | 3d | 2016-01-13 | 2016-01-16 | 70FS+1d | 0d |  | NC [800%] | 192h | 3,54 | 6,38 | 23 | 100m2 |
| 72 | 1.3.4.5 | GCLD VK dÇm, sµn 75% (h<16m) | 8d | 2016-01-14 | 2016-01-22 | 71SS+1d | 0d |  | NC [1900%] | 1216h | 9,41 | 16,09 | 151 | 100m2 |
| 73 | 1.3.4.6 | GCLD cèt thÐp dÇm, sµn (h<16m) | 7d | 2016-01-15 | 2016-01-22 | 72SS+1d | 0d |  | NC [1000%] | 560h | 7,71 | 9,17 | 71 |  |
| 74 | 1.3.4.7 | §æ BT dÇm, sµn b»ng m¸y b¬m (60m3/h) 70% | 1d | 2016-01-22 | 2016-01-23 | 73, 72 | 0d |  | NC [2000%] | 160h | 98,19 | 20 c«ng/ca |  | m3 |
| 75 | 1.3.4.8 | Th¸o dì v¸n khu«n dÇm, sµn 25% | 6d | 2016-02-14 | 2016-02-20 | 74FS+23d | 0d |  | NC [800%] | 384h | 9,41 | 5,36 | 50 | 100m2 |
| 76 | 1.3.4.9 | X©y t­êng chÌn (h<16m) | 17d | 2016-02-20 | 2016-03-07 | 75, 60 | 0d |  | NC [1700%] | 2312h | 148,9 | 1,97 | 293 | m3 |
| 77 | 1.3.4.10 | GCLD VK cÇu thang 75% ( h<16m) | 1d | 2016-02-23 | 2016-02-24 | 76SS+4d | 90d | 0d | NC [500%] | 40h | 0,31 | 16,09 |  | 100m2 |
| 78 | 1.3.4.11 | GCLD cèt thÐp cÇu thang 75% ( h<16m) | 1d | 2016-02-24 | 2016-02-25 | 77 | 90d | 0d | NC [400%] | 32h | 0,3 | 14,63 |  |  |
| 79 | 1.3.4.12 | §æ BT cÇu thang b»ng thñ c«ng | 1d | 2016-02-25 | 2016-02-26 | 78, 77 | 90d | 0d | NC [1100%] | 88h | 3,95 | 2,9 | 11 | m3 |
| 80 | 1.3.4.13 | Th¸o dì VK cÇu thang 25% | 1d | 2016-03-04 | 2016-03-05 | 79FS+7d | 90d |  | NC [200%] | 16h | 0,31 | 5,36 |  | 100m2 |
| 81 | 1.3.4.14 | Tr¸t t­êng trong + trÇn | 17d | 2016-03-07 | 2016-03-23 | 76, 65 | 0d |  | NC [2300%] | 3128h | 1917,87 | 0.2 | 384 | m2 |
| 82 | 1.3.4.15 | L¸t nÒn, sµn | 5d | 2016-05-05 | 2016-05-10 | 98 | 8d | 0d | NC [2100%] | 840h | 610,75 | 0,17 | 104 | m2 |
| 83 | 1.3.5 | **tÇng 5** | 106d | 2016-01-24 | 2016-05-05 |  | 0d |  |  | 10584h |  |  |  |  |
| 84 | 1.3.5.1 | GCLD cèt thÐp cét, v¸ch lâi thang m¸y (h <50m) d> 18mm | 3d | 2016-01-24 | 2016-01-26 | 74FS+1d | 0d |  | NC [1700%] | 408h | 5,09 | 9,74 | 50 |  |
| 85 | 1.3.5.2 | GCLD VK cét, v¸ch lâi thang m¸y 75% (h<50m) | 3d | 2016-01-24 | 2016-01-27 | 84SS+1d | 0d |  | NC [2200%] | 528h | 3,54 | 18,56 | 66 | 100m2 |
| 86 | 1.3.5.3 | §æ BT cét, v¸ch lâi thang m¸y b»ng b¬m (60m3/h) 70% | 1d | 2016-01-27 | 2016-01-28 | 85, 84 | 0d |  | NC [2000%] | 160h | 32,44 | 20 c«ng/ca |  | m3 |
| 87 | 1.3.5.4 | Th¸o dì VK cét , v¸ch lâi thang m¸y 25%(h<50m) | 4d | 2016-01-29 | 2016-02-02 | 86FS+1d | 0d |  | NC [600%] | 192h | 3,54 | 6,19 | 22 | 100m2 |
| 88 | 1.3.5.5 | GCLD VK dÇm, sµn 75% (h<50m) | 8d | 2016-01-30 | 2016-02-07 | 87SS+1d | 0d |  | NC [2100%] | 1344h | 9,41 | 17,73 | 167 | 100m2 |
| 89 | 1.3.5.6 | GCLD cèt thÐp dÇm, sµn (h<50m) | 7d | 2016-01-31 | 2016-02-07 | 88SS+1d | 0d |  | NC [1100%] | 616h | 7,71 | 10,1 | 78 |  |
| 90 | 1.3.5.7 | §æ BT dÇm, sµn b»ng m¸y b¬m (60m3/h) 70% | 1d | 2016-02-07 | 2016-02-08 | 89, 88 | 0d |  | NC [2000%] | 160h | 98,19 | 20 c«ng/ca |  | m3 |
| 91 | 1.3.5.8 | Th¸o dì v¸n khu«n dÇm, sµn 25% | 6d | 2016-03-01 | 2016-03-07 | 90FS+23d | 0d |  | NC [900%] | 432h | 9,41 | 5,91 | 56 | 100m2 |
| 92 | 1.3.5.9 | X©y t­êng chÌn (h<50m) | 17d | 2016-03-07 | 2016-03-23 | 91, 76 | 0d |  | NC [1900%] | 2584h | 148,9 | 2,16 | 322 | m3 |
| 93 | 1.3.5.10 | GCLD VK cÇu thang 75% ( h<50m) | 1d | 2016-03-12 | 2016-03-13 | 92SS+5d | 72d | 0d | NC [600%] | 48h | 0,31 | 17,73 |  | 100m2 |
| 94 | 1.3.5.11 | GCLD cèt thÐp cÇu thang 75% ( h<50m) | 1d | 2016-03-13 | 2016-03-14 | 93 | 72d | 0d | NC [500%] | 40h | 0,3 | 15,85 |  |  |
| 95 | 1.3.5.12 | §æ BT cÇu thang b»ng thñ c«ng | 1d | 2016-03-14 | 2016-03-15 | 93, 94 | 72d | 0d | NC [1100%] | 88h | 3,95 | 2,9 | 11 | m3 |
| 96 | 1.3.5.13 | Th¸o dì VK cÇu thang 25% | 1d | 2016-03-21 | 2016-03-22 | 95FS+7d | 72d |  | NC [200%] | 16h | 0,31 | 5,91 |  | 100m2 |
| 97 | 1.3.5.14 | Tr¸t t­êng trong + trÇn | 17d | 2016-03-23 | 2016-04-09 | 92, 81 | 0d |  | NC [2300%] | 3128h | 1917,87 | 0.2 | 384 | m2 |
| 98 | 1.3.5.15 | L¸t nÒn, sµn | 5d | 2016-04-30 | 2016-05-05 | 114 | 8d | 0d | NC [2100%] | 840h | 610,75 | 0,17 | 104 | m2 |

| ID | WBS | Task | Duration | Start | Finish | Predecessors | Total slack | Free slack | Resources | Work | Text2 | Text3 | Text4 | Text1 |
| --- | --- | --- | --- | --- | --- | --- | --- | --- | --- | --- | --- | --- | --- | --- |
| 99 | 1.3.6 | **tÇng 6** | 84d | 2016-02-09 | 2016-04-30 |  | 0d |  |  | 10584h |  |  |  |  |
| 100 | 1.3.6.1 | GCLD cèt thÐp cét, v¸ch lâi thang m¸y (h <50m) d> 18mm | 3d | 2016-02-09 | 2016-02-12 | 90FS+1d | 0d |  | NC [1700%] | 408h | 5,09 | 9,74 | 50 |  |
| 101 | 1.3.6.2 | GCLD VK cét, v¸ch lâi thang m¸y 75% (h<50m) | 3d | 2016-02-10 | 2016-02-13 | 100SS+1d | 0d |  | NC [2200%] | 528h | 3,54 | 18,56 | 66 | 100m2 |
| 102 | 1.3.6.3 | §æ BT cét, v¸ch lâi thang m¸y b»ng b¬m (60m3/h) 70% | 1d | 2016-02-13 | 2016-02-14 | 100, 101 | 0d |  | NC [2000%] | 160h | 32,44 | 20 c«ng/ca |  | m3 |
| 103 | 1.3.6.4 | Th¸o dì VK cét , v¸ch lâi thang m¸y 25%(h<50m) | 4d | 2016-02-15 | 2016-02-19 | 102FS+1d | 0d |  | NC [600%] | 192h | 3,54 | 6,19 | 22 | 100m2 |
| 104 | 1.3.6.5 | GCLD VK dÇm, sµn 75% (h<50m) | 8d | 2016-02-16 | 2016-02-23 | 103SS+1d | 0d |  | NC [2100%] | 1344h | 9,41 | 17,73 | 167 | 100m2 |
| 105 | 1.3.6.6 | GCLD cèt thÐp dÇm, sµn (h<50m) | 7d | 2016-02-17 | 2016-02-23 | 104SS+1d | 0d |  | NC [1100%] | 616h | 7,71 | 10,1 | 78 |  |
| 106 | 1.3.6.7 | §æ BT dÇm, sµn b»ng m¸y b¬m(60m3/h) 70% | 1d | 2016-02-23 | 2016-02-24 | 105, 104 | 0d |  | NC [2000%] | 160h | 98,19 | 20 c«ng/ca |  | m3 |
| 107 | 1.3.6.8 | Th¸o dì v¸n khu«n dÇm, sµn 25% | 6d | 2016-03-18 | 2016-03-23 | 106FS+23d | 0d |  | NC [900%] | 432h | 9,41 | 5,91 | 56 | 100m2 |
| 108 | 1.3.6.9 | X©y t­êng chÌn (h<50m) | 17d | 2016-03-23 | 2016-04-09 | 107, 92 | 0d |  | NC [1900%] | 2584h | 148,9 | 2,16 | 322 | m3 |
| 109 | 1.3.6.10 | GCLD VK cÇu thang 75% ( h<50m) | 1d | 2016-03-28 | 2016-03-29 | 108SS+5d | 55d | 0d | NC [600%] | 48h | 0,31 | 17,73 |  | 100m2 |
| 110 | 1.3.6.11 | GCLD cèt thÐp cÇu thang 75% ( h<50m) | 1d | 2016-03-29 | 2016-03-30 | 109 | 55d | 0d | NC [500%] | 40h | 0,3 | 15,85 |  |  |
| 111 | 1.3.6.12 | §æ BT cÇu thang b»ng thñ c«ng | 1d | 2016-03-30 | 2016-03-31 | 109, 110 | 55d | 0d | NC [1100%] | 88h | 3,95 | 2,9 | 11 | m3 |
| 112 | 1.3.6.13 | Th¸o dì VK cÇu thang 25% | 1d | 2016-04-07 | 2016-04-08 | 111FS+7d | 55d |  | NC [200%] | 16h | 0,31 | 5,91 |  | 100m2 |
| 113 | 1.3.6.14 | Tr¸t t­êng trong + trÇn | 17d | 2016-04-09 | 2016-04-25 | 108, 97 | 0d |  | NC [2300%] | 3128h | 1917,87 | 0.2 | 384 | m2 |
| 114 | 1.3.6.15 | L¸t nÒn, sµn | 5d | 2016-04-25 | 2016-04-30 | 113 | 8d | 0d | NC [2100%] | 840h | 610,75 | 0,17 | 104 | m2 |
| 115 | 1.3.7 | **tÇng 7** | 79d | 2016-02-25 | 2016-05-12 |  | 0d |  |  | 9744h |  |  |  |  |
| 116 | 1.3.7.1 | GCLD cèt thÐp cét, v¸ch lâi thang m¸y (h <50m) d> 18mm | 3d | 2016-02-25 | 2016-02-28 | 106FS+1d | 0d |  | NC [1700%] | 408h | 5,09 | 9,74 | 50 |  |
| 117 | 1.3.7.2 | GCLD VK cét, v¸ch lâi thang m¸y 75% (h<50m) | 3d | 2016-02-26 | 2016-02-29 | 116SS+1d | 0d |  | NC [2200%] | 528h | 3,54 | 18,56 | 66 | 100m2 |
| 118 | 1.3.7.3 | §æ BT cét, v¸ch lâi thang m¸y b»ng b¬m (60m3/h) 70% | 1d | 2016-02-29 | 2016-03-01 | 116, 117 | 0d |  | NC [2000%] | 160h | 32,44 | 20 c«ng/ca |  | m3 |
| 119 | 1.3.7.4 | Th¸o dì VK cét , v¸ch lâi thang m¸y 25%(h<50m) | 4d | 2016-03-02 | 2016-03-06 | 118FS+1d | 0d |  | NC [600%] | 192h | 3,54 | 6,19 | 22 | 100m2 |
| 120 | 1.3.7.5 | GCLD VK dÇm, sµn 75% (h<50m) | 8d | 2016-03-03 | 2016-03-11 | 119SS+1d | 0d |  | NC [2100%] | 1344h | 9,41 | 17,73 | 167 | 100m2 |
| 121 | 1.3.7.6 | GCLD cèt thÐp dÇm, sµn (h<50m) | 7d | 2016-03-04 | 2016-03-11 | 120SS+1d | 0d |  | NC [1100%] | 616h | 7,71 | 10,1 | 78 |  |
| 122 | 1.3.7.7 | §æ BT dÇm, sµn b»ng m¸y b¬m (60m3/h) 70% | 1d | 2016-03-11 | 2016-03-12 | 120, 121 | 0d |  | NC [2000%] | 160h | 98,19 | 20 c«ng/ca |  | m3 |
| 123 | 1.3.7.8 | Th¸o dì v¸n khu«n dÇm, sµn 25% | 6d | 2016-04-03 | 2016-04-09 | 122FS+23d | 0d |  | NC [900%] | 432h | 9,41 | 5,91 | 56 | 100m2 |
| 124 | 1.3.7.9 | X©y t­êng chÌn (h<50m) | 17d | 2016-04-09 | 2016-04-25 | 123, 108 | 0d |  | NC [1900%] | 2584h | 148,9 | 2,16 | 322 | m3 |
| 125 | 1.3.7.10 | GCLD VK cÇu thang 75% ( h<50m) | 1d | 2016-04-14 | 2016-04-15 | 124SS+5d | 38d | 0d | NC [600%] | 48h | 0,31 | 17,73 |  | 100m2 |
| 126 | 1.3.7.11 | GCLD cèt thÐp cÇu thang 75% ( h<50m) | 1d | 2016-04-15 | 2016-04-16 | 125 | 38d | 0d | NC [500%] | 40h | 0,3 | 15,85 |  |  |
| 127 | 1.3.7.12 | §æ BT cÇu thang b»ng thñ c«ng | 1d | 2016-04-16 | 2016-04-16 | 125, 126 | 38d | 0d | NC [1100%] | 88h | 3,95 | 2,9 | 11 | m3 |
| 128 | 1.3.7.13 | Th¸o dì VK cÇu thang 25% | 1d | 2016-04-23 | 2016-04-24 | 127FS+7d | 38d |  | NC [200%] | 16h | 0,31 | 5,91 |  | 100m2 |
| 129 | 1.3.7.14 | Tr¸t t­êng trong + trÇn | 17d | 2016-04-25 | 2016-05-12 | 124, 113 | 0d |  | NC [2300%] | 3128h | 1917,87 | 0.2 | 384 | m2 |

| ID | WBS | Task | Type | Duration | Start | Finish | Predecessors | Total slack | Free slack | Constraint | Resources | Work | Text1 | Text2 | Text3 | Text4 |
| --- | --- | --- | --- | --- | --- | --- | --- | --- | --- | --- | --- | --- | --- | --- | --- | --- |
| 130 | 1.3.8 | **Khèi l­îng tÇng m¸i** |  | 7d | 2016-04-25 | 2016-05-02 |  | 13d |  |  |  | 880h |  |  |  |  |
| 131 | 1.3.8.1 | X©y t­êng thu håi |  | 4d | 2016-04-25 | 2016-04-29 | 124 | 13d | 0d |  | NC [2100%] | 672h | m3 | 36,3 | 2,33 | 85 |
| 132 | 1.3.8.2 | L¾p dùng xµ gå m¸I ( thÐp) |  | 1d | 2016-04-29 | 2016-04-30 | 131 | 30d | 0d |  | NC [400%] | 32h | m3 | 1,3 | 2,73 |  |
| 133 | 1.3.8.3 | Lîp t«n mói |  | 2d | 2016-04-30 | 2016-05-02 | 132 | 30d |  |  | NC [1100%] | 176h | 100m2 | 4,7 | 4,5 | 21 |
| 134 | 1.4 | **Khèi l­îng hoµn thiÖn** |  | 195d | 2015-11-25 | 2016-05-31 |  | 0d |  |  |  | 12008h |  |  |  |  |
| 135 | 1.4.1 | B¶o d­ìng BT | milestone | 123d | 2015-11-25 | 2016-03-22 | 22 | 72d |  | finish no earlier than 2016-03-19 | NC [200%] | 1968h | c«ng |  |  |  |
| 136 | 1.4.2 | Tr¸t t­êng ngoµi toµn bé |  | 20d | 2016-04-29 | 2016-05-18 | 131 | 13d |  |  | NC [2100%] | 3360h | m2 | 1921,84 | 0,22 | 423 |
| 137 | 1.4.3 | S¬n t­êng toµn bé c«ng tr×nh |  | 20d | 2016-05-12 | 2016-05-31 | 129, 34FF | 0d |  |  | NC [3200%] | 5120h | m2 | 15464,08 | 0,04 | 649 |
| 138 | 1.4.4 | L¾p cöa vµo khu«n toµn bé |  | 15d | 2016-05-15 | 2016-05-29 | 137SS+3d | 2d |  |  | NC [1300%] | 1560h | m2 | 770 | 0,25 | 193 |
